# FirstBaseline_FabAcademy

Schedule from MS Project, 2019-01-23 to 2019-06-12, A marks actual dates.

## Calendars

- Estándar: Mon-Fri 09:00-13:00, 15:00-19:00; Sat-Sun off. Exceptions (off unless hours are given): 2019-02-04 (Constitución), 2019-03-18 (Benito Juárez), 2019-04-15 to 2019-04-19 (Semana Santa), 2019-05-01 (Día del trabajo).

## Resources

| Resource |
| --- |
| Lettyrf |
| Rafa |
| Carlos |

## Schedule

| ID | WBS | Task | Duration | Start | Finish | Predecessors | Complete | Remaining | Baseline start | Baseline finish | Baseline duration | Total slack | Free slack | Constraint | Resources | Work | Actual work |
| --- | --- | --- | --- | --- | --- | --- | --- | --- | --- | --- | --- | --- | --- | --- | --- | --- | --- |
| 1 | 1 | **Final Project** | 92d | 2019-01-23 A | 2019-06-12 |  | 5% | 87.07d | 2019-01-23 | 2019-06-11 | 92d | 1d |  |  |  | 1448h | 84h |
| 2 | 1.1 | Define Objective | 1d | 2019-01-23 A | 2019-01-23 A |  | 100% |  | 2019-01-23 | 2019-01-23 | 1d |  |  |  | Lettyrf | 8h | 8h |
| 3 | 1.2 | Sketch | 2d | 2019-01-24 A | 2019-01-25 A | 2 | 100% |  | 2019-01-24 | 2019-01-25 | 2d |  |  |  | Lettyrf | 16h | 16h |
| 4 | 1.3 | Definition of Story to develop | 5d | 2019-01-28 A | 2019-02-01 A | 3 | 100% |  | 2019-01-28 | 2019-02-01 | 5d |  |  |  | Lettyrf | 40h | 40h |
| 5 | 1.4 | Transcribing of Story in Spanish | 5d | 2019-02-05 | 2019-02-11 | 4 |  |  |  |  |  | 18d | 0d |  |  |  |  |
| 6 | 1.5 | Re-Interpretation of Story in English | 10d | 2019-02-12 | 2019-02-25 | 5 |  |  |  |  |  | 18d | 17d |  |  |  |  |
| 7 | 1.6 | Definition of Characters | 5d | 2019-02-05 A | 2019-02-11 | 4 | 25% | 3.75d | 2019-02-05 | 2019-02-11 | 5d | 42d | 0d |  | Lettyrf | 40h | 10h |
| 8 | 1.7 | **Scenario** | 48d | 2019-01-30 A | 2019-04-09 |  | 3% | 46.78d | 2019-01-30 | 2019-04-09 | 48d | 28d |  |  |  | 392h | 10h |
| 9 | 1.7.1 | CAD for scenario | 5d | 2019-01-30 A | 2019-02-06 |  | 25% | 3.75d | 2019-01-30 | 2019-02-06 | 5d | 27d | 0d | start no earlier than 2019-01-30 | Lettyrf | 40h | 10h |
| 10 | 1.7.2 | CNC cutting and building | 5d | 2019-02-07 | 2019-02-13 | 9 |  |  | 2019-02-07 | 2019-02-13 | 5d | 27d | 0d |  | Lettyrf | 40h |  |
| 11 | 1.7.3 | Scenario finishing touches | 15d | 2019-02-14 | 2019-03-06 | 10 |  |  | 2019-02-14 | 2019-03-06 | 15d | 51d | 50d |  | Lettyrf | 120h |  |
| 12 | 1.7.4 | **Electronics** | 38d | 2019-02-14 | 2019-04-09 | 10 |  |  | 2019-02-14 | 2019-04-09 | 38d | 13d |  |  |  | 192h |  |
| 13 | 1.7.4.1 | Definition of mechanisms to move characters | 9d | 2019-02-14 | 2019-02-26 | 9 |  |  | 2019-02-14 | 2019-02-26 | 9d | 27d | 0d |  | Lettyrf | 72h |  |
| 14 | 1.7.4.2 | Electronics design for grid | 5d | 2019-02-27 | 2019-03-05 | 13 |  |  | 2019-02-27 | 2019-03-05 | 5d | 27d | 14d |  | Lettyrf | 40h |  |
| 15 | 1.7.4.3 | Electronics to sync with app - input | 5d | 2019-03-27 | 2019-04-02 | 14 |  |  | 2019-03-27 | 2019-04-02 | 5d | 13d | 0d | start no earlier than 2019-03-27 | Lettyrf | 40h |  |
| 16 | 1.7.4.4 | Electronics to sync with app - output | 5d | 2019-04-03 | 2019-04-09 | 15 |  |  | 2019-04-03 | 2019-04-09 | 5d | 13d | 0d |  | Lettyrf | 40h |  |
| 17 | 1.8 | **App Development** | 61d | 2019-02-20 | 2019-05-24 |  |  |  | 2019-02-20 | 2019-05-24 | 61d | 1d |  |  |  | 608h |  |
| 18 | 1.8.1 | App Mock-Up | 3d | 2019-02-20 | 2019-02-22 | 4 |  |  | 2019-02-20 | 2019-02-22 | 3d | 1d | 0d | start no earlier than 2019-02-20 | Lettyrf | 24h |  |
| 19 | 1.8.2 | Scenography Design | 5d | 2019-02-25 | 2019-03-01 | 18 |  |  | 2019-02-25 | 2019-03-01 | 5d | 1d | 0d |  | Lettyrf | 40h |  |
| 20 | 1.8.3 | Data Base definition | 3d | 2019-03-04 | 2019-03-06 | 19 |  |  | 2019-03-04 | 2019-03-06 | 3d | 1d | 0d |  | Lettyrf | 24h |  |
| 21 | 1.8.4 | App Architecture | 5d | 2019-03-07 | 2019-03-13 | 20 |  |  | 2019-03-07 | 2019-03-13 | 5d | 1d | 0d |  | Lettyrf | 40h |  |
| 22 | 1.8.5 | Development of menus | 5d | 2019-03-14 | 2019-03-21 | 21 |  |  | 2019-03-14 | 2019-03-21 | 5d | 1d | 0d |  | Lettyrf | 40h |  |
| 23 | 1.8.6 | Development of Scenographies | 10d | 2019-03-22 | 2019-04-04 | 22, 6 |  |  | 2019-03-22 | 2019-04-04 | 10d | 1d | 0d |  | Lettyrf | 80h |  |
| 24 | 1.8.7 | Synchronization of audio | 10d | 2019-04-05 | 2019-04-25 | 23 |  |  | 2019-04-05 | 2019-04-25 | 10d | 1d | 0d |  | Lettyrf | 80h |  |
| 25 | 1.8.8 | Synchronization subtitles | 10d | 2019-04-26 | 2019-05-10 | 24 |  |  | 2019-04-26 | 2019-05-10 | 10d | 1d | 0d |  | Lettyrf | 80h |  |
| 26 | 1.8.9 | App Testing | 10d | 2019-05-13 | 2019-05-24 | 25 |  |  | 2019-05-13 | 2019-05-24 | 10d | 1d | 0d |  | Lettyrf | 80h |  |
| 27 | 1.8.10 | Control Sync with Electronics | 15d | 2019-04-10 | 2019-05-08 | 16 |  |  | 2019-04-10 | 2019-05-08 | 15d | 13d | 12d |  | Lettyrf | 120h |  |

| ID | WBS | Task | Type | Duration | Start | Finish | Predecessors | Complete | Remaining | Baseline start | Baseline finish | Baseline duration | Total slack | Free slack | Constraint | Resources | Work | Actual work |
| --- | --- | --- | --- | --- | --- | --- | --- | --- | --- | --- | --- | --- | --- | --- | --- | --- | --- | --- |
| 28 | 1.9 | **Characters** |  | 30d | 2019-02-12 | 2019-03-26 |  |  |  | 2019-02-12 | 2019-03-26 | 30d | 42d |  |  |  | 248h |  |
| 29 | 1.9.1 | Definition of technique to be used |  | 6d | 2019-02-12 | 2019-02-19 | 7 |  |  | 2019-02-12 | 2019-02-19 | 6d | 42d | 0d |  | Lettyrf | 48h |  |
| 30 | 1.9.2 | 3D printing of characters |  | 5d | 2019-02-20 | 2019-02-26 | 29 |  |  | 2019-02-20 | 2019-02-26 | 5d | 42d | 0d |  | Lettyrf | 40h |  |
| 31 | 1.9.3 | Molding and casting of characters |  | 5d | 2019-03-20 | 2019-03-26 | 30 |  |  | 2019-03-20 | 2019-03-26 | 5d | 50d |  | start no earlier than 2019-03-20 | Lettyrf | 40h |  |
| 32 | 1.9.4 | Character's finishing touches |  | 15d | 2019-02-27 | 2019-03-20 | 30 |  |  | 2019-02-27 | 2019-03-20 | 15d | 42d | 41d |  | Lettyrf | 120h |  |
| 33 | 1.10 | Integral testing |  | 10d | 2019-05-27 | 2019-06-07 | 26, 27, 32, 11, 16 |  |  | 2019-05-27 | 2019-06-07 | 10d | 1d | 0d |  | Lettyrf | 80h |  |
| 34 | 1.11 | Presentation Preparation |  | 2d | 2019-06-10 | 2019-06-11 | 33 |  |  | 2019-06-10 | 2019-06-11 | 2d | 1d | 0d |  | Lettyrf | 16h |  |
| 35 | 1.12 | Presentation | milestone | 0d | 2019-06-12 | 2019-06-12 | 34 |  |  | 2019-06-11 | 2019-06-11 | 0d | 1d |  | start no earlier than 2019-06-12 | Lettyrf |  |  |
| 36 | 2 | **Assignments** |  | 93d? | 2019-01-23 A | 2019-06-12 |  | 50% | 46.74d? | 2019-01-23 | 2019-06-12 | 93d | 0d |  |  |  | 1056h | 466h |
| 37 | 2.1 | **W2: Project Management** |  | 3d | 2019-01-23 A | 2019-01-26 A |  | 100% |  | 2019-01-23 | 2019-01-29 | 5d |  |  |  |  | 48h | 48h |
| 38 | 2.1.1 | Web Page Structure |  | 1d | 2019-01-23 A | 2019-01-23 A |  | 100% |  | 2019-01-23 | 2019-01-29 | 5d |  |  |  | Lettyrf | 8h | 8h |
| 39 | 2.1.2 | Week 1: assignments |  | 1d | 2019-01-24 A | 2019-01-24 A | 38 | 100% |  |  |  |  |  |  | finish no earlier than 2019-01-23 | Lettyrf | 8h | 8h |
| 40 | 2.1.3 | Git set-up tutorial |  | 1d | 2019-01-25 A | 2019-01-26 A | 39 | 100% |  |  |  |  |  |  |  | Lettyrf | 8h | 8h |
| 41 | 2.1.4 | Web set-up tutorial | milestone | 0d | 2019-01-26 A | 2019-01-26 A | 40 | 100% |  |  |  |  |  |  |  | Lettyrf |  |  |
| 42 | 2.1.5 | Set first baseline |  | 3d | 2019-01-23 A | 2019-01-26 A |  | 100% |  | 2019-01-23 | 2019-01-29 | 5d |  |  |  | Lettyrf | 24h | 24h |
| 43 | 2.2 | **W3: CAD** |  | 4d | 2019-01-30 A | 2019-02-05 A |  | 100% |  | 2019-01-30 | 2019-02-05 | 4d |  |  |  |  | 32h | 32h |
| 44 | 2.2.1 | **Individual Activity** |  | 4d | 2019-01-30 A | 2019-02-05 A |  | 100% |  | 2019-01-30 | 2019-02-05 | 4d |  |  |  |  | 32h | 32h |
| 45 | 2.2.1.1 | AutoCAD |  | 1d | 2019-01-30 A | 2019-01-30 A | 38, 42 | 100% |  |  |  |  |  |  | start no earlier than 2019-01-30 | Lettyrf | 8h | 8h |
| 46 | 2.2.1.2 | SolidWorks |  | 1d | 2019-01-31 A | 2019-01-31 A | 45 | 100% |  |  |  |  |  |  |  | Lettyrf | 8h | 8h |
| 47 | 2.2.1.3 | Fusion 360 |  | 1d | 2019-02-01 A | 2019-02-01 A | 46 | 100% |  |  |  |  |  |  |  | Lettyrf | 8h | 8h |
| 48 | 2.2.1.4 | Model First CAD model for final project |  | 1d | 2019-02-05 A | 2019-02-05 A | 47 | 100% |  |  |  |  |  |  |  | Lettyrf | 8h | 8h |
| 49 | 2.2.2 | Update Week 3 Individual activity | milestone | 0d | 2019-02-05 A | 2019-02-05 A | 44 | 100% |  | 2019-02-05 | 2019-02-05 | 0d |  |  |  | Lettyrf |  |  |
| 50 | 2.3 | **W4: CNC Cutting** |  | 5d | 2019-02-06 A | 2019-02-12 A |  | 100% |  | 2019-02-06 | 2019-02-12 | 5d |  |  |  |  | 56h | 56h |
| 51 | 2.3.1 | Group activity |  | 1d | 2019-02-06 A | 2019-02-06 A | 49 | 100% |  | 2019-02-06 | 2019-02-06 | 1d |  |  |  | Lettyrf; Rafa; Carlos | 24h | 24h |
| 52 | 2.3.2 | Update week 4: Group Activity | milestone | 0d | 2019-02-06 A | 2019-02-06 A | 51 | 100% |  | 2019-02-06 | 2019-02-06 | 0d |  |  |  | Lettyrf |  |  |
| 53 | 2.3.3 | Individual activity |  | 4d | 2019-02-07 A | 2019-02-12 A | 52 | 100% |  | 2019-02-07 | 2019-02-12 | 4d |  |  |  | Lettyrf | 32h | 32h |
| 54 | 2.3.4 | Update Week 4: Individual Activity | milestone | 0d | 2019-02-12 A | 2019-02-12 A | 53 | 100% |  | 2019-02-12 | 2019-02-12 | 0d |  |  |  | Lettyrf |  |  |

| ID | WBS | Task | Type | Duration | Start | Finish | Predecessors | Complete | Remaining | Baseline start | Baseline finish | Baseline duration | Total slack | Free slack | Resources | Work | Actual work |
| --- | --- | --- | --- | --- | --- | --- | --- | --- | --- | --- | --- | --- | --- | --- | --- | --- | --- |
| 55 | 2.4 | **W5: Electronics Production** |  | 5d | 2019-02-13 A | 2019-02-19 A |  | 100% |  | 2019-02-13 | 2019-02-19 | 5d |  |  |  | 40h | 40h |
| 56 | 2.4.1 | Individual Activity |  | 5d | 2019-02-13 A | 2019-02-19 A | 54 | 100% |  | 2019-02-13 | 2019-02-19 | 5d |  |  | Lettyrf | 40h | 40h |
| 57 | 2.4.2 | Update week5: Individual Activy | milestone | 0d | 2019-02-19 A | 2019-02-19 A | 56 | 100% |  | 2019-02-19 | 2019-02-19 | 0d |  |  | Lettyrf |  |  |
| 58 | 2.5 | **W6: 3D Scanning and Printing** |  | 24d? | 2019-01-23 A | 2019-02-26 A |  | 100% |  | 2019-02-20 | 2019-02-26 | 5d |  |  |  | 56h | 56h |
| 59 | 2.5.1 | Group Activity |  | 1d | 2019-02-20 A | 2019-02-20 A | 57 | 100% |  | 2019-02-20 | 2019-02-20 | 1d |  |  | Lettyrf; Rafa; Carlos | 24h | 24h |
| 60 | 2.5.2 | Update Week 5: Group Activity | milestone | 0d | 2019-02-20 A | 2019-02-20 A | 59 | 100% |  | 2019-02-20 | 2019-02-20 | 0d |  |  | Lettyrf |  |  |
| 61 | 2.5.3 | Individual Activity: Scan and print |  | 4d | 2019-02-21 A | 2019-02-26 A | 60 | 100% |  | 2019-02-21 | 2019-02-26 | 4d |  |  | Lettyrf | 32h | 32h |
| 62 | 2.5.4 | Individual Activity: Design and print |  | 1d? | 2019-01-23 A | 2019-01-23 A |  | 100% |  |  |  |  |  |  |  |  |  |
| 63 | 2.5.5 | Update week 5: Individual Activy | milestone | 0d | 2019-02-26 A | 2019-02-26 A | 61 | 100% |  | 2019-02-26 | 2019-02-26 | 0d |  |  | Lettyrf |  |  |
| 64 | 2.6 | **W7: Electronic Design** |  | 5d | 2019-02-27 A | 2019-03-05 A |  | 100% |  | 2019-02-27 | 2019-03-05 | 5d |  |  |  | 56h | 56h |
| 65 | 2.6.1 | Group Activity |  | 1d | 2019-02-27 A | 2019-02-27 A | 63 | 100% |  | 2019-02-27 | 2019-02-27 | 1d |  |  | Lettyrf; Rafa; Carlos | 24h | 24h |
| 66 | 2.6.2 | Update week6: Group Activity | milestone | 0d | 2019-02-27 A | 2019-02-27 A | 65 | 100% |  | 2019-02-27 | 2019-02-27 | 0d |  |  | Lettyrf |  |  |
| 67 | 2.6.3 | Individual Activity |  | 4d | 2019-02-28 A | 2019-03-05 A | 66 | 100% |  | 2019-02-28 | 2019-03-05 | 4d |  |  | Lettyrf | 32h | 32h |
| 68 | 2.6.4 | Update week 6 : Individual Activity | milestone | 0d | 2019-03-05 A | 2019-03-05 A | 67 | 100% |  | 2019-03-05 | 2019-03-05 | 0d |  |  | Lettyrf |  |  |
| 69 | 2.7 | **W8: CNC Machining** |  | 5d | 2019-03-06 A | 2019-03-12 A |  | 100% |  | 2019-03-06 | 2019-03-12 | 5d |  |  |  | 56h | 56h |
| 70 | 2.7.1 | Group Activity |  | 1d | 2019-03-06 A | 2019-03-06 A | 68 | 100% |  | 2019-03-06 | 2019-03-06 | 1d |  |  | Lettyrf; Rafa; Carlos | 24h | 24h |
| 71 | 2.7.2 | Update week 8: group activity | milestone | 0d | 2019-03-06 A | 2019-03-06 A | 70 | 100% |  | 2019-03-06 | 2019-03-06 | 0d |  |  | Lettyrf |  |  |
| 72 | 2.7.3 | Individual Activity - Make something big |  | 4d | 2019-03-07 A | 2019-03-12 A | 71 | 100% |  | 2019-03-07 | 2019-03-12 | 4d |  |  | Lettyrf | 32h | 32h |
| 73 | 2.7.4 | Update week 8: individual activity | milestone | 0d | 2019-03-12 A | 2019-03-12 A | 72 | 100% |  | 2019-03-12 | 2019-03-12 | 0d |  |  | Lettyrf |  |  |
| 74 | 2.8 | **W9: Embedded Programming** |  | 4d | 2019-03-13 A | 2019-03-19 |  | 63% | 1.5d | 2019-03-13 | 2019-03-19 | 4d | 55d |  |  | 48h | 36h |
| 75 | 2.8.1 | Group Activity |  | 1d | 2019-03-13 A | 2019-03-13 A | 73 | 100% |  | 2019-03-13 | 2019-03-13 | 1d |  |  | Lettyrf; Rafa; Carlos | 24h | 24h |
| 76 | 2.8.2 | Update week 9: Group activity | milestone | 0d | 2019-03-13 | 2019-03-13 | 75 |  |  | 2019-03-13 | 2019-03-13 | 0d | 1.5d | 0d | Lettyrf |  |  |
| 77 | 2.8.3 | Individual Activity |  | 3d | 2019-03-14 A | 2019-03-19 | 76 | 50% | 1.5d | 2019-03-14 | 2019-03-19 | 3d | 55d | 0d | Lettyrf | 24h | 12h |
| 78 | 2.8.4 | Update week 9: Individual activity | milestone | 0d | 2019-03-19 | 2019-03-19 | 77 |  |  | 2019-03-19 | 2019-03-19 | 0d | 55d |  | Lettyrf |  |  |

| ID | WBS | Task | Type | Duration | Start | Finish | Predecessors | Complete | Remaining | Baseline start | Baseline finish | Baseline duration | Total slack | Free slack | Resources | Work | Actual work |
| --- | --- | --- | --- | --- | --- | --- | --- | --- | --- | --- | --- | --- | --- | --- | --- | --- | --- |
| 79 | 2.9 | **W10: Molding and Casting** |  | 5d | 2019-03-20 A | 2019-03-26 |  | 99% | 0d | 2019-03-20 | 2019-03-26 | 5d | 50d |  |  | 56h | 56h |
| 80 | 2.9.1 | Group Activity |  | 1d | 2019-03-20 A | 2019-03-20 A | 78 | 100% |  | 2019-03-20 | 2019-03-20 | 1d |  |  | Lettyrf; Rafa; Carlos | 24h | 24h |
| 81 | 2.9.2 | update week 10: group activity | milestone | 0d | 2019-03-20 | 2019-03-20 | 80 |  |  | 2019-03-20 | 2019-03-20 | 0d | 54d |  | Lettyrf |  |  |
| 82 | 2.9.3 | Individual Activity |  | 4d | 2019-03-21 A | 2019-03-26 A | 81 | 100% |  | 2019-03-21 | 2019-03-26 | 4d |  |  | Lettyrf | 32h | 32h |
| 83 | 2.9.4 | update week 10: individual activity | milestone | 0d | 2019-03-26 | 2019-03-26 | 82 |  |  | 2019-03-26 | 2019-03-26 | 0d | 3.75d | 0d | Lettyrf |  |  |
| 84 | 2.10 | **W11: Input Devices** |  | 5d | 2019-03-27 A | 2019-04-02 |  |  | 5d | 2019-03-27 | 2019-04-02 | 5d | 3.75d |  |  | 56h |  |
| 85 | 2.10.1 | Group Activity |  | 1d | 2019-03-27 | 2019-03-27 | 83 |  |  | 2019-03-27 | 2019-03-27 | 1d | 3.75d | 0d | Lettyrf; Rafa; Carlos | 24h |  |
| 86 | 2.10.2 | Update week 11: Group activity | milestone | 0d | 2019-03-27 | 2019-03-27 | 85 |  |  | 2019-03-27 | 2019-03-27 | 0d | 3.75d | 0d | Lettyrf |  |  |
| 87 | 2.10.3 | Individual Activity |  | 4d | 2019-03-28 | 2019-04-02 | 86 |  |  | 2019-03-28 | 2019-04-02 | 4d | 3.75d | 0d | Lettyrf | 32h |  |
| 88 | 2.10.4 | Update week 11: individual activity | milestone | 0d | 2019-04-02 A | 2019-04-02 | 87 | 30% | 0d | 2019-04-02 | 2019-04-02 | 0d | 3.75d | 0d | Lettyrf |  |  |
| 89 | 2.11 | **W12: Output Devices** |  | 5d | 2019-04-03 | 2019-04-09 |  |  |  | 2019-04-03 | 2019-04-09 | 5d | 3.75d |  |  | 56h |  |
| 90 | 2.11.1 | Group Activity |  | 1d | 2019-04-03 | 2019-04-03 | 88 |  |  | 2019-04-03 | 2019-04-03 | 1d | 3.75d | 0d | Lettyrf; Rafa; Carlos | 24h |  |
| 91 | 2.11.2 | Update week 12: group activity | milestone | 0d | 2019-04-03 | 2019-04-03 | 90 |  |  | 2019-04-03 | 2019-04-03 | 0d | 3.75d | 0d | Lettyrf |  |  |
| 92 | 2.11.3 | Individual Activity |  | 4d | 2019-04-04 | 2019-04-09 | 91 |  |  | 2019-04-04 | 2019-04-09 | 4d | 3.75d | 0d | Lettyrf | 32h |  |
| 93 | 2.11.4 | Update week 12: individual activity | milestone | 0d | 2019-04-09 | 2019-04-09 | 92 |  |  | 2019-04-09 | 2019-04-09 | 0d | 3.75d | 0d | Lettyrf |  |  |
| 94 | 2.12 | **W13: Applications and Implications** |  | 5d | 2019-04-10 A | 2019-04-23 |  | 75% | 1.25d | 2019-04-10 | 2019-04-23 | 5d | 0d |  |  | 40h | 30h |
| 95 | 2.12.1 | Individual Activity |  | 5d | 2019-04-10 A | 2019-04-23 | 93 | 75% | 1.25d | 2019-04-10 | 2019-04-23 | 5d | 0d |  | Lettyrf | 40h | 30h |
| 96 | 2.12.2 | Update week 13: Individual activity | milestone | 0d | 2019-04-23 A | 2019-04-23 | 95 | 75% | 0d | 2019-04-23 | 2019-04-23 | 0d | 0d |  | Lettyrf |  |  |
| 97 | 2.13 | **W14: Networking and Communications** |  | 5d | 2019-04-24 | 2019-04-30 |  |  |  | 2019-04-24 | 2019-04-30 | 5d | 0d |  |  | 56h |  |
| 98 | 2.13.1 | Group Activity |  | 1d | 2019-04-24 | 2019-04-24 | 96 |  |  | 2019-04-24 | 2019-04-24 | 1d | 0d |  | Lettyrf; Rafa; Carlos | 24h |  |
| 99 | 2.13.2 | Update week 14: group activity | milestone | 0d | 2019-04-24 | 2019-04-24 | 98 |  |  | 2019-04-24 | 2019-04-24 | 0d | 0d |  | Lettyrf |  |  |
| 100 | 2.13.3 | Individual Activity |  | 4d | 2019-04-25 | 2019-04-30 | 99 |  |  | 2019-04-25 | 2019-04-30 | 4d | 0d |  | Lettyrf | 32h |  |
| 101 | 2.13.4 | update week 14: individual activity | milestone | 0d | 2019-04-30 | 2019-04-30 | 100 |  |  | 2019-04-30 | 2019-04-30 | 0d | 0d |  | Lettyrf |  |  |
| 102 | 2.14 | **W15: Mechanical Design** |  | 5d | 2019-05-02 | 2019-05-08 |  |  |  | 2019-05-02 | 2019-05-08 | 5d | 0d |  |  | 120h |  |
| 103 | 2.14.1 | Group Activity |  | 5d | 2019-05-02 | 2019-05-08 | 101 |  |  | 2019-05-02 | 2019-05-08 | 5d | 0d |  | Lettyrf; Rafa; Carlos | 120h |  |
| 104 | 2.14.2 | Update week 15: group activity | milestone | 0d | 2019-05-08 | 2019-05-08 | 103 |  |  | 2019-05-08 | 2019-05-08 | 0d | 0d |  | Lettyrf |  |  |

| ID | WBS | Task | Type | Duration | Start | Finish | Predecessors | Baseline start | Baseline finish | Baseline duration | Total slack | Resources | Work |
| --- | --- | --- | --- | --- | --- | --- | --- | --- | --- | --- | --- | --- | --- |
| 105 | 2.15 | **W16: Interface and Application Programming** |  | 5d | 2019-05-09 | 2019-05-15 |  | 2019-05-09 | 2019-05-15 | 5d | 0d |  | 56h |
| 106 | 2.15.1 | Group Activity |  | 1d | 2019-05-09 | 2019-05-09 | 104 | 2019-05-09 | 2019-05-09 | 1d | 0d | Lettyrf; Rafa; Carlos | 24h |
| 107 | 2.15.2 | update week 16: group activity | milestone | 0d | 2019-05-09 | 2019-05-09 | 106 | 2019-05-09 | 2019-05-09 | 0d | 0d | Lettyrf |  |
| 108 | 2.15.3 | Individual Activity |  | 4d | 2019-05-10 | 2019-05-15 | 107 | 2019-05-10 | 2019-05-15 | 4d | 0d | Lettyrf | 32h |
| 109 | 2.15.4 | Update week 16: individual activity | milestone | 0d | 2019-05-15 | 2019-05-15 | 108 | 2019-05-15 | 2019-05-15 | 0d | 0d | Lettyrf |  |
| 110 | 2.16 | **W17: Machine Design** |  | 4d | 2019-05-16 | 2019-05-21 |  | 2019-05-16 | 2019-05-21 | 4d | 0d |  | 96h |
| 111 | 2.16.1 | Group Activity |  | 4d | 2019-05-16 | 2019-05-21 | 109 | 2019-05-16 | 2019-05-21 | 4d | 0d | Lettyrf; Rafa; Carlos | 96h |
| 112 | 2.16.2 | Update week 17: group activity | milestone | 0d | 2019-05-21 | 2019-05-21 | 111 | 2019-05-21 | 2019-05-21 | 0d | 0d | Lettyrf |  |
| 113 | 2.17 | **W18: Wildcard Week** |  | 4d | 2019-05-22 | 2019-05-27 |  | 2019-05-22 | 2019-05-27 | 4d | 0d |  | 32h |
| 114 | 2.17.1 | Individual Activity |  | 4d | 2019-05-22 | 2019-05-27 | 112 | 2019-05-22 | 2019-05-27 | 4d | 0d | Lettyrf | 32h |
| 115 | 2.17.2 | Update week 18: individual activity | milestone | 0d | 2019-05-27 | 2019-05-27 | 114 | 2019-05-27 | 2019-05-27 | 0d | 0d | Lettyrf |  |
| 116 | 2.18 | **W19: Invention, Intellectual Property, and Income** |  | 4d | 2019-05-28 | 2019-05-31 |  | 2019-05-28 | 2019-05-31 | 4d | 0d |  | 32h |
| 117 | 2.18.1 | Individual Activity |  | 4d | 2019-05-28 | 2019-05-31 | 115 | 2019-05-28 | 2019-05-31 | 4d | 0d | Lettyrf | 32h |
| 118 | 2.18.2 | Update week 19: individual activity | milestone | 0d | 2019-05-31 | 2019-05-31 | 117 | 2019-05-31 | 2019-05-31 | 0d | 0d | Lettyrf |  |
| 119 | 2.19 | **W20: Project Development** |  | 4d | 2019-06-03 | 2019-06-06 |  | 2019-06-03 | 2019-06-06 | 4d | 0d |  | 32h |
| 120 | 2.19.1 | Individual Activity |  | 4d | 2019-06-03 | 2019-06-06 | 118 | 2019-06-03 | 2019-06-06 | 4d | 0d | Lettyrf | 32h |
| 121 | 2.19.2 | Update week 20: individual activity | milestone | 0d | 2019-06-06 | 2019-06-06 | 120 | 2019-06-06 | 2019-06-06 | 0d | 0d | Lettyrf |  |
| 122 | 2.20 | **W21: Project Presentations** |  | 4d | 2019-06-07 | 2019-06-12 |  | 2019-06-07 | 2019-06-12 | 4d | 0d |  | 32h |
| 123 | 2.20.1 | Individual activity |  | 4d | 2019-06-07 | 2019-06-12 | 121 | 2019-06-07 | 2019-06-12 | 4d | 0d | Lettyrf | 32h |
| 124 | 2.20.2 | Update week 21: individual activity | milestone | 0d | 2019-06-12 | 2019-06-12 | 123 | 2019-06-12 | 2019-06-12 | 0d | 0d | Lettyrf |  |
